# Productieschema ontwerpproces woning

Schedule from MS Project, 2004-01-05 to 2004-05-21.
BAM Nelissen Van Egteren

## Calendars

- Standaard: Mon-Fri 08:30-12:30, 13:00-17:00; Sat-Sun off.

## Schedule

| ID | WBS | Task | Type | Duration | Start | Finish | Predecessors | Total slack | Free slack |
| --- | --- | --- | --- | --- | --- | --- | --- | --- | --- |
| 1 | 1 | **INITIATIEF** |  | 15d | 2004-01-05 | 2004-01-23 |  | 85d |  |
| 2 | 1.1 | leuke bouwkavel gezien |  | 1w | 2004-01-05 | 2004-01-09 |  | 95d |  |
| 3 | 1.2 | discussie over nieuwe woning |  | 2w | 2004-01-05 | 2004-01-16 |  | 85d | 0d |
| 4 | 1.3 | overleg voorwaarden met makelaar |  | 1w | 2004-01-19 | 2004-01-23 | 3 | 85d | 0d |
| 5 | 1.4 | besluit: haalbaarheid onderzoeken | milestone | 0w | 2004-01-23 | 2004-01-23 | 4 | 85d |  |
| 7 | 2 | **HAALBAARHEID** |  | 30d | 2004-01-05 | 2004-02-13 |  | 70d |  |
| 8 | 2.1 | **programmeren** |  | 20d | 2004-01-05 | 2004-01-30 |  | 70d |  |
| 9 | 2.1.1 | functioneel: analyse woonwensen |  | 1w | 2004-01-05 | 2004-01-09 |  | 75d | 0d |
| 10 | 2.1.2 | ruimtelijk: analyse aantal ruimtes |  | 1w | 2004-01-12 | 2004-01-16 | 9 | 75d | 0d |
| 11 | 2.1.3 | technisch: analyse kwaliteitsniveau |  | 1w | 2004-01-19 | 2004-01-23 | 10 | 75d | 0d |
| 12 | 2.1.4 | financieel: analyse woonlasten |  | 1w | 2004-01-26 | 2004-01-30 | 11 | 75d | 0d |
| 13 | 2.2 | **beoordelen en besluiten** |  | 10d | 2004-02-02 | 2004-02-13 | 12 | 70d |  |
| 14 | 2.2.1 | financiering beoordelen |  | 2w | 2004-02-02 | 2004-02-13 |  | 70d | 0d |
| 15 | 2.2.2 | besluit: het is haalbaar | milestone | 0w | 2004-02-13 | 2004-02-13 | 14 | 70d |  |
| 17 | 3 | **PROJECTDEFINITIE** |  | 30d | 2004-01-05 | 2004-02-13 |  | 70d |  |
| 18 | 3.1 | **programmeren** |  | 20d | 2004-01-05 | 2004-01-30 |  | 70d |  |
| 19 | 3.1.1 | functioneel program: woonwensen |  | 2w | 2004-01-05 | 2004-01-16 |  | 70d | 0d |
| 20 | 3.1.2 | ruimtelijk program: ruimtelijke wensen |  | 2w | 2004-01-19 | 2004-01-30 | 19 | 80d |  |
| 21 | 3.1.3 | technisch program: materiaalkeuze |  | 2w | 2004-01-05 | 2004-01-16 | 19SS | 70d | 0d |
| 22 | 3.1.4 | financieel program: woonlasten |  | 2w | 2004-01-19 | 2004-01-30 | 21 | 70d | 0d |
| 23 | 3.2 | **beoordelen en besluiten** |  | 10d | 2004-02-02 | 2004-02-13 |  | 70d |  |
| 24 | 3.2.1 | beoordelen woonwensen met budget |  | 2w | 2004-02-02 | 2004-02-13 | 22 | 70d | 0d |
| 25 | 3.2.2 | besluit tot start ontwerpproces | milestone | 0w | 2004-02-13 | 2004-02-13 | 24 | 70d |  |
| 27 | 4 | **STRUCTUUR ONTWERP** |  | 55d | 2004-01-05 | 2004-03-19 |  | 45d |  |
| 28 | 4.1 | **organiseren** |  | 20d | 2004-01-05 | 2004-01-30 |  | 45d |  |
| 29 | 4.1.1 | selecteren architect |  | 1w | 2004-01-05 | 2004-01-09 |  | 45d | 0d |
| 30 | 4.1.2 | overleg met architect over program |  | 1w | 2004-01-12 | 2004-01-16 | 29 | 45d | 0d |
| 31 | 4.1.3 | opstellen ontwerpopdracht |  | 1w | 2004-01-19 | 2004-01-23 | 30 | 45d | 0d |
| 32 | 4.1.4 | tekenen ontwerpopdracht | milestone | 0w | 2004-01-23 | 2004-01-23 | 31 | 45d | 0d |
| 33 | 4.1.5 | plan van aanpak opstellen |  | 1w | 2004-01-26 | 2004-01-30 | 32 | 45d | 0d |

| ID | WBS | Task | Type | Duration | Start | Finish | Predecessors | Total slack | Free slack |
| --- | --- | --- | --- | --- | --- | --- | --- | --- | --- |
| 34 | 4.2 | **ontwerpen** |  | 20d | 2004-02-02 | 2004-02-27 |  | 45d |  |
| 35 | 4.2.1 | ontwerp varianten tekenen |  | 2w | 2004-02-02 | 2004-02-13 | 33 | 45d | 0d |
| 36 | 4.2.2 | overleg met opdrachtgever |  | 1w | 2004-02-16 | 2004-02-20 | 35 | 45d | 0d |
| 37 | 4.2.3 | structuurontwerp aanpassen |  | 1w | 2004-02-23 | 2004-02-27 | 36 | 45d | 0d |
| 38 | 4.3 | **begroten-beoordelen+besluiten** |  | 15d | 2004-03-01 | 2004-03-19 |  | 45d |  |
| 39 | 4.3.1 | elementcluster begroting opstellen |  | 1w | 2004-03-01 | 2004-03-05 | 37 | 45d | 0d |
| 40 | 4.3.2 | voldoet ontwerp aan programma |  | 1w | 2004-03-08 | 2004-03-12 | 39 | 45d | 0d |
| 41 | 4.3.3 | voldoet ontwerp aan bouwbudget |  | 1w | 2004-03-15 | 2004-03-19 | 40 | 45d | 0d |
| 42 | 4.3.4 | besluiten: structuurontwerp accoord | milestone | 0w | 2004-03-19 | 2004-03-19 | 41 | 45d |  |
| 44 | 5 | **VOORLOPIG ONTWERP** |  | 65d | 2004-01-05 | 2004-04-02 |  | 35d |  |
| 45 | 5.1 | **organiseren+programmeren** |  | 10d | 2004-01-05 | 2004-01-16 |  | 35d |  |
| 46 | 5.1.1 | plan van aanpak uitwerken |  | 1w | 2004-01-05 | 2004-01-09 |  | 35d | 0d |
| 47 | 5.1.2 | woning programma actualiseren |  | 1w | 2004-01-12 | 2004-01-16 | 46 | 35d | 0d |
| 48 | 5.2 | **ontwerpen** |  | 35d | 2004-01-19 | 2004-03-05 |  | 35d |  |
| 49 | 5.2.1 | plattegronden tekenen |  | 2w | 2004-01-19 | 2004-01-30 | 47 | 35d | 0d |
| 50 | 5.2.2 | draagstructuur tekenen |  | 2w | 2004-02-02 | 2004-02-13 | 49 | 70d |  |
| 51 | 5.2.3 | gevels tekenen |  | 2w | 2004-02-02 | 2004-02-13 | 49 | 35d | 0d |
| 52 | 5.2.4 | overleg met opdrachtgever |  | 1w | 2004-02-16 | 2004-02-20 | 51 | 35d | 0d |
| 53 | 5.2.5 | voorlopig ontwerp aanpassen |  | 2w | 2004-02-23 | 2004-03-05 | 52 | 35d | 0d |
| 54 | 5.3 | **begroten-beoordelen+besluiten** |  | 20d | 2004-03-08 | 2004-04-02 |  | 35d |  |
| 55 | 5.3.1 | elementenbegroting maken |  | 2w | 2004-03-08 | 2004-03-19 | 53 | 35d | 0d |
| 56 | 5.3.2 | voldoet ontwerp aan program |  | 1w | 2004-03-22 | 2004-03-26 | 55 | 35d | 0d |
| 57 | 5.3.3 | voldoet ontwerp aan budget |  | 1w | 2004-03-29 | 2004-04-02 | 56 | 35d | 0d |
| 58 | 5.3.4 | accoord: start definitief ontwerp | milestone | 0w | 2004-04-02 | 2004-04-02 | 57 | 35d |  |

| ID | WBS | Task | Type | Duration | Start | Finish | Predecessors | Total slack | Free slack |
| --- | --- | --- | --- | --- | --- | --- | --- | --- | --- |
| 60 | 6 | **DEFINITIEF ONTWERP** |  | 60d | 2004-01-05 | 2004-03-26 |  | 40d |  |
| 61 | 6.1 | **organiseren+programmeren** |  | 5d | 2004-01-05 | 2004-01-09 |  | 40d |  |
| 62 | 6.1.1 | plan van aanpak uitwerken |  | 1w | 2004-01-05 | 2004-01-09 |  | 40d | 0d |
| 63 | 6.1.2 | woning programma actualiseren |  | 1w | 2004-01-05 | 2004-01-09 | 62SS | 40d | 0d |
| 64 | 6.2 | **ontwerpen** |  | 35d | 2004-01-12 | 2004-02-27 |  | 40d |  |
| 65 | 6.2.1 | plattegronden tekenen |  | 2w | 2004-01-12 | 2004-01-23 | 63 | 40d | 0d |
| 66 | 6.2.2 | draagstructuur tekenen |  | 2w | 2004-01-26 | 2004-02-06 | 65 | 75d |  |
| 67 | 6.2.3 | gevels tekenen |  | 2w | 2004-01-26 | 2004-02-06 | 65 | 40d | 0d |
| 68 | 6.2.4 | overleg met opdrachtgever |  | 1w | 2004-02-09 | 2004-02-13 | 67 | 40d | 0d |
| 69 | 6.2.5 | voorlopig ontwerp aanpassen |  | 2w | 2004-02-16 | 2004-02-27 | 68 | 40d | 0d |
| 70 | 6.3 | **begroten-beoordelen+besluiten** |  | 20d | 2004-03-01 | 2004-03-26 |  | 40d |  |
| 71 | 6.3.1 | elementenbegroting maken |  | 2w | 2004-03-01 | 2004-03-12 | 69 | 40d | 0d |
| 72 | 6.3.2 | voldoet ontwerp aan programma |  | 1w | 2004-03-15 | 2004-03-19 | 71 | 40d | 0d |
| 73 | 6.3.3 | voldoet ontwerp aan bouwbudget |  | 1w | 2004-03-22 | 2004-03-26 | 72 | 40d | 0d |
| 74 | 6.3.4 | accoord: start bestek&tekening | milestone | 0w | 2004-03-26 | 2004-03-26 | 73 | 40d |  |
| 76 | 7 | **BESTEK & TEKENING** |  | 35d | 2004-01-05 | 2004-02-20 |  | 65d |  |
| 77 | 7.1 | **organiseren+programmeren** |  | 5d | 2004-01-05 | 2004-01-09 |  | 65d |  |
| 78 | 7.1.1 | plan van aanpak uitwerken |  | 1w | 2004-01-05 | 2004-01-09 |  | 65d | 0d |
| 79 | 7.1.2 | woning programma actualiseren |  | 1w | 2004-01-05 | 2004-01-09 | 78SS | 65d | 0d |
| 80 | 7.2 | **ontwerpen** |  | 20d | 2004-01-12 | 2004-02-06 |  | 65d |  |
| 81 | 7.2.1 | bouwkundige bestektekeningen |  | 2w | 2004-01-12 | 2004-01-23 | 79 | 65d | 0d |
| 82 | 7.2.2 | constructie bestektekening |  | 2w | 2004-01-26 | 2004-02-06 | 81 | 75d |  |
| 83 | 7.2.3 | installatie bestektekening |  | 2w | 2004-01-26 | 2004-02-06 | 81 | 75d |  |
| 84 | 7.2.4 | bouwkundig bestek schrijven |  | 4w | 2004-01-12 | 2004-02-06 | 81SS | 65d | 0d |

| ID | WBS | Task | Type | Duration | Start | Finish | Predecessors | Total slack | Free slack |
| --- | --- | --- | --- | --- | --- | --- | --- | --- | --- |
| 85 | 7.3 | **begroten-beoordelen+besluiten** |  | 10d | 2004-02-09 | 2004-02-20 |  | 65d |  |
| 86 | 7.3.1 | voldoet bestek aan programma |  | 1w | 2004-02-09 | 2004-02-13 | 84 | 65d | 0d |
| 87 | 7.3.2 | voldoet bestek aan bouwbudget |  | 1w | 2004-02-16 | 2004-02-20 | 86 | 65d | 0d |
| 88 | 7.3.3 | accoord: start aanbesteding | milestone | 0w | 2004-02-20 | 2004-02-20 | 87 | 65d |  |
| 90 | 8 | **PRIJSVORMING** |  | 65d | 2004-01-05 | 2004-04-02 |  | 35d |  |
| 91 | 8.1 | **organiseren** |  | 20d | 2004-01-05 | 2004-01-30 |  | 35d |  |
| 92 | 8.1.1 | selecteren aannemers |  | 2w | 2004-01-05 | 2004-01-16 |  | 35d | 0d |
| 93 | 8.1.2 | uitnodiging voor aanbesteding |  | 1w | 2004-01-19 | 2004-01-23 | 92 | 35d | 0d |
| 94 | 8.1.3 | afgifte bestek aan aannemers |  | 1w | 2004-01-26 | 2004-01-30 | 93 | 35d | 0d |
| 95 | 8.2 | **begroten** |  | 20d | 2004-02-02 | 2004-02-27 |  | 35d |  |
| 96 | 8.2.1 | aannemers inschrijfbegroting |  | 4w | 2004-02-02 | 2004-02-27 | 94 | 35d | 0d |
| 97 | 8.2.2 | dag van aanbesteding | milestone | 0w | 2004-02-27 | 2004-02-27 | 96 | 35d | 0d |
| 98 | 8.3 | **beoordelen+besluiten** |  | 25d | 2004-03-01 | 2004-04-02 |  | 35d |  |
| 99 | 8.3.1 | voldoet prijs aan bouwbudget |  | 2w | 2004-03-01 | 2004-03-12 | 97 | 35d | 0d |
| 100 | 8.3.2 | prijsoverleg met laagste inschrijver |  | 2w | 2004-03-15 | 2004-03-26 | 99 | 35d | 0d |
| 101 | 8.3.3 | opstellen aannemingsovereenkomst |  | 1w | 2004-03-29 | 2004-04-02 | 100 | 35d | 0d |
| 102 | 8.3.4 | bouwopdracht tekenen | milestone | 0w | 2004-04-02 | 2004-04-02 | 101 | 35d |  |
| 104 | 9 | **WERKVOORBEREIDING** |  | 25d | 2004-01-05 | 2004-02-06 |  | 75d |  |
| 105 | 9.1 | **organiseren** |  | 25d | 2004-01-05 | 2004-02-06 |  | 75d |  |
| 106 | 9.1.1 | productieschema maken |  | 1w | 2004-01-05 | 2004-01-09 |  | 75d | 0d |
| 107 | 9.1.2 | procedure inkoop materialen |  | 4w | 2004-01-12 | 2004-02-06 | 106 | 75d |  |
| 108 | 9.1.3 | procedure onderaannemers |  | 4w | 2004-01-12 | 2004-02-06 | 106 | 75d |  |
| 109 | 9.2 | **ontwerpen uitwerken** |  | 20d | 2004-01-12 | 2004-02-06 |  | 75d |  |
| 110 | 9.2.1 | bouwkundige werktekeningen |  | 4w | 2004-01-12 | 2004-02-06 | 106 | 75d |  |
| 111 | 9.2.2 | constructieve werktekeningen |  | 4w | 2004-01-12 | 2004-02-06 | 106 | 75d |  |
| 112 | 9.2.3 | installatie werktekeningen |  | 4w | 2004-01-12 | 2004-02-06 | 106 | 75d |  |

| ID | WBS | Task | Type | Duration | Start | Finish | Predecessors | Total slack | Free slack |
| --- | --- | --- | --- | --- | --- | --- | --- | --- | --- |
| 114 | 10 | **UITVOERING WONING** |  | 100d | 2004-01-05 | 2004-05-21 |  | 0d |  |
| 115 | 10.1 | aanloopfase |  | 3w | 2004-01-05 | 2004-01-23 |  | 0d |  |
| 116 | 10.2 | onderbouwfase |  | 3w | 2004-01-26 | 2004-02-13 | 115 | 0d |  |
| 117 | 10.3 | bovenbouwfase |  | 3w | 2004-02-16 | 2004-03-05 | 116 | 0d |  |
| 118 | 10.4 | gevel/dakfase |  | 3w | 2004-03-08 | 2004-03-26 | 117 | 0d |  |
| 119 | 10.5 | afbouwfase |  | 8w | 2004-03-29 | 2004-05-21 | 118 | 0d |  |
| 121 | 11 | **OPLEVERING + INHUIZING WONING** |  | 25d | 2004-01-05 | 2004-02-06 |  | 75d |  |
| 122 | 11.1 | vooropname en gebreken reistreren |  | 1w | 2004-01-05 | 2004-01-09 |  | 75d | 0d |
| 123 | 11.2 | gebreken vooraf herstellen |  | 1w | 2004-01-12 | 2004-01-16 | 122 | 75d | 0d |
| 124 | 11.3 | formele oplevering | milestone | 0w | 2004-01-16 | 2004-01-16 | 123 | 75d | 0d |
| 125 | 11.4 | gebreken herstellen |  | 3w | 2004-01-19 | 2004-02-06 | 124 | 75d |  |
| 126 | 11.5 | inrichten door bewoner |  | 2w | 2004-01-19 | 2004-01-30 | 124SS | 80d | 0d |
| 127 | 11.6 | overhuizen naar nieuwe woning | milestone | 0w | 2004-01-30 | 2004-01-30 | 126 | 80d |  |
